# preliminary schedule for manufacturing and delivery

Schedule from MS Project, 2025-10-31 to 2030-11-11.

## Calendars

- Standard: Mon-Fri 08:00-12:00, 13:00-17:00; Sat-Sun off.

## Resources

| Resource |
| --- |
| Litgrid |

## Schedule

| ID | WBS | Task | Type | Duration | Start | Finish | Predecessors | Total slack | Free slack | Constraint | Resources | Work |
| --- | --- | --- | --- | --- | --- | --- | --- | --- | --- | --- | --- | --- |
| 1 | 1 | **Contract term** |  | 1311d | 2025-10-31 | 2030-11-11 |  | 0d |  |  |  | 15120h |
| 2 | 1.1 | Contract signing | milestone, manual | 0d | 2025-10-31 | 2025-10-31 |  |  |  |  |  |  |
| 3 | 1.2 | Prepayment if any |  | 1emo | 2025-10-31 | 2025-11-30 | 2 | 5420.1d |  |  |  |  |
| 4 | 1.3 | Approved of the project documentation for all three VSR |  | 3.33emo | 2025-10-31 | 2026-02-08 | 2 | 0d |  |  |  |  |
| 5 | 1.4 | **Shunt reactor for Musa and Darbenai** |  | 505d | 2026-02-08 | 2028-01-17 |  | 735d |  |  |  | 2160h |
| 6 | 1.4.1 | Waiting period |  | 14.67emo | 2026-02-08 | 2027-04-24 | 4 | 3086.1d | 0d | finish no earlier than 2027-04-20 |  |  |
| 7 | 1.4.2 | manufacturing and FAT test |  | 4emo | 2027-04-24 | 2027-08-22 | 6 | 3086.1d | 0d |  |  |  |
| 8 | 1.4.3 | Item is ready to Ship. |  | 2ew | 2027-08-22 | 2027-09-05 | 7 | 3086.1d | 0d |  |  |  |
| 9 | 1.4.4 | Transportation |  | 1emo | 2027-09-05 | 2027-10-05 | 8 | 3086.1d | 0d |  |  |  |
| 10 | 1.4.5 | Installation |  | 3emo | 2027-10-05 | 2028-01-03 | 9 | 3086.1d | 0d |  | Litgrid | 2160h |
| 11 | 1.4.6 | Supervision Services |  | 2ew | 2028-01-03 | 2028-01-17 | 10 | 3086.1d |  |  |  |  |
| 12 | 1.5 | **Shunt reactor for Gizai** |  | 1240d | 2026-02-08 | 2030-11-11 |  | 0d |  |  |  | 12960h |
| 13 | 1.5.1 | Waiting period |  | 34emo | 2026-02-08 | 2028-11-24 | 4 | 0d |  |  |  |  |
| 14 | 1.5.2 | manufacturing and FAT test |  | 3.96emo | 2028-11-24 | 2029-03-23 | 13 | 0d |  |  |  |  |
| 15 | 1.5.3 | Item is ready to Ship. |  | 2ew | 2029-03-23 | 2029-04-06 | 14 | 0d |  |  |  |  |
| 16 | 1.5.4 | Transportation |  | 1emo | 2029-04-06 | 2029-05-06 | 15 | 0d |  |  |  |  |
| 17 | 1.5.5 | Installation |  | 18emo | 2029-05-06 | 2030-10-28 | 16 | 0d |  |  | Litgrid | 12960h |
| 18 | 1.5.6 | Supervision Service |  | 2ew | 2030-10-28 | 2030-11-11 | 17 | 0d |  |  |  |  |
